# SAGA WBS Phase 2

Schedule from MS Project, 2012-01-09 to 2012-06-06.
ODU Computer Science

## Calendars

- Standard: Mon-Fri 08:00-12:00, 13:00-17:00; Sat-Sun off.

## Schedule

| ID | WBS | Task | Duration | Start | Finish | Predecessors | Total slack | Free slack | Constraint |
| --- | --- | --- | --- | --- | --- | --- | --- | --- | --- |
| 1 | 1 | **Phase 1** | 108d | 2012-01-09 | 2012-06-06 |  | 0d |  |  |
| 2 | 1.1 | **Develop Project Team** | 14d | 2012-01-09 | 2012-01-26 |  | 64d |  |  |
| 3 | 1.1.1 | Interview/Hire Database Developer | 14d | 2012-01-09 | 2012-01-26 |  | 64d |  | start no earlier than 2012-01-09 |
| 4 | 1.1.2 | Interview/Hire Software Developer | 14d | 2012-01-09 | 2012-01-26 |  | 64d |  |  |
| 5 | 1.1.3 | Interview/Hire GUI Developer | 14d | 2012-01-09 | 2012-01-26 |  | 64d |  |  |
| 6 | 1.1.4 | Interview/Hire Documentation Specialist | 14d | 2012-01-09 | 2012-01-26 |  | 64d |  |  |
| 7 | 1.2 | **Planning** | 20d | 2012-01-09 | 2012-02-03 |  | 0d |  |  |
| 8 | 1.2.1 | Hardware Plan | 10d | 2012-01-09 | 2012-01-20 |  | 10d |  |  |
| 9 | 1.2.2 | Software Plan | 20d | 2012-01-09 | 2012-02-03 |  | 0d |  |  |
| 10 | 1.3 | **Hardware** | 6d | 2012-02-06 | 2012-02-13 | 7 | 0d |  |  |
| 11 | 1.3.1 | Research workstation brand/model | 1d | 2012-02-06 | 2012-02-06 |  | 0d |  |  |
| 12 | 1.3.2 | Purchase workstations | 5d | 2012-02-07 | 2012-02-13 | 11 | 0d |  |  |
| 13 | 1.3.3 | Research server brand/model | 1d | 2012-02-06 | 2012-02-06 |  | 0d |  |  |
| 14 | 1.3.4 | Purchase server | 5d | 2012-02-07 | 2012-02-13 | 13 | 0d |  |  |
| 15 | 1.4 | **Prototype/Simulation Development** | 52d | 2012-02-14 | 2012-04-25 | 10, 7, 2 | 0d |  |  |
| 16 | 1.4.1 | **GUI** | 20d | 2012-02-14 | 2012-03-12 | 10, 32 | 32d |  |  |
| 17 | 1.4.1.1 | Analysis | 3d | 2012-02-14 | 2012-02-16 |  | 32d | 0d | start no earlier than 2012-02-14 |
| 18 | 1.4.1.2 | Design | 5d | 2012-02-17 | 2012-02-23 | 17 | 32d | 0d |  |
| 19 | 1.4.1.3 | Implementation | 10d | 2012-02-24 | 2012-03-08 | 18 | 32d | 0d |  |
| 20 | 1.4.1.4 | Testing | 2d | 2012-03-09 | 2012-03-12 | 19 | 32d |  |  |
| 21 | 1.4.2 | **Algorithms** | 45d | 2012-02-14 | 2012-04-16 | 9 | 7d |  |  |
| 22 | 1.4.2.1 | Virtual Checkpoint Allocation Algorithm | 45d | 2012-02-14 | 2012-04-16 |  | 7d |  |  |
| 23 | 1.4.2.2 | GPS Data Collection Algorithm | 10d | 2012-02-14 | 2012-02-27 |  | 42d |  |  |
| 24 | 1.4.2.3 | Route Analysis Algorithm | 20d | 2012-02-14 | 2012-03-12 |  | 32d |  |  |
| 25 | 1.4.2.4 | Congestion Notification Algorithm | 10d | 2012-02-14 | 2012-02-27 |  | 42d |  |  |

| ID | WBS | Task | Duration | Start | Finish | Predecessors | Total slack | Free slack |
| --- | --- | --- | --- | --- | --- | --- | --- | --- |
| 26 | 1.4.3 | **Databases** | 52d | 2012-02-14 | 2012-04-25 |  | 0d |  |
| 27 | 1.4.3.1 | Analysis | 5d | 2012-02-14 | 2012-02-20 |  | 0d |  |
| 28 | 1.4.3.2 | Design | 15d | 2012-02-21 | 2012-03-12 | 27 | 0d |  |
| 29 | 1.4.3.3 | Implementation | 12d | 2012-03-13 | 2012-03-28 | 28 | 0d |  |
| 30 | 1.4.3.4 | Integration | 10d | 2012-03-29 | 2012-04-11 | 29 | 0d |  |
| 31 | 1.4.3.5 | Testing | 10d | 2012-04-12 | 2012-04-25 | 30 | 0d |  |
| 32 | 1.4.4 | **Hardware Interface** | 38d | 2012-02-14 | 2012-04-05 |  | 14d |  |
| 33 | 1.4.4.1 | Analysis | 3d | 2012-02-14 | 2012-02-16 |  | 14d | 0d |
| 34 | 1.4.4.2 | Design | 7d | 2012-02-17 | 2012-02-27 | 33 | 14d | 0d |
| 35 | 1.4.4.3 | Implementation | 14d | 2012-02-28 | 2012-03-16 | 34 | 14d | 0d |
| 36 | 1.4.4.4 | Testing | 14d | 2012-03-19 | 2012-04-05 | 35 | 14d |  |
| 37 | 1.4.5 | **Data Simulation** | 17d | 2012-02-14 | 2012-03-07 | 10 | 35d |  |
| 38 | 1.4.5.1 | Analysis | 4d | 2012-02-14 | 2012-02-17 |  | 35d | 0d |
| 39 | 1.4.5.2 | Design | 7d | 2012-02-20 | 2012-02-28 | 38 | 35d | 0d |
| 40 | 1.4.5.3 | Implementation | 4d | 2012-02-29 | 2012-03-05 | 39 | 35d | 0d |
| 41 | 1.4.5.4 | Validation | 2d | 2012-03-06 | 2012-03-07 | 40 | 35d |  |
| 42 | 1.4.6 | **Traffic Analysis Engine Simulation** | 32d | 2012-02-14 | 2012-03-28 | 10 | 20d |  |
| 43 | 1.4.6.1 | Analysis | 7d | 2012-02-14 | 2012-02-22 |  | 45d |  |
| 44 | 1.4.6.2 | Design | 10d | 2012-02-14 | 2012-02-27 |  | 20d | 0d |
| 45 | 1.4.6.3 | Implementation | 15d | 2012-02-28 | 2012-03-19 | 44 | 20d | 0d |
| 46 | 1.4.6.4 | Testing | 7d | 2012-03-20 | 2012-03-28 | 45 | 20d |  |
| 47 | 1.5 | **Documentation** | 7d | 2012-04-26 | 2012-05-04 | 15 | 23d |  |
| 48 | 1.5.1 | Database Documents | 5d | 2012-04-26 | 2012-05-02 |  | 25d |  |
| 49 | 1.5.2 | Algorithm Documents | 7d | 2012-04-26 | 2012-05-04 |  | 23d |  |
| 50 | 1.5.3 | Hardware Interface Documents | 5d | 2012-04-26 | 2012-05-02 |  | 25d |  |
| 51 | 1.5.4 | Data Mining Documents | 5d | 2012-04-26 | 2012-05-02 |  | 25d |  |
| 52 | 1.5.5 | Traffic Analysis Engine Documents | 5d | 2012-04-26 | 2012-05-02 |  | 25d |  |
| 53 | 1.5.6 | GUI Documents | 5d | 2012-04-26 | 2012-05-02 |  | 25d |  |
| 54 | 1.6 | Prototype Testing | 30d | 2012-04-26 | 2012-06-06 | 15, 2 | 0d |  |
